# Short Film Project

Schedule from MS Project, 2005-03-07 to 2006-01-06, costs in $, A marks actual dates.

## Calendars

- Standard: Mon-Fri 08:00-12:00, 13:00-17:00; Sat-Sun off.
- Evening Shoot: Mon-Fri 17:00-23:00; Sat-Sun off.
- Night Shift: Mon 23:00-24:00; Tue-Fri 00:00-03:00, 04:00-08:00, 23:00-24:00; Sat 00:00-03:00, 04:00-08:00; Sun off.

## Resources

| Resource | Group | Unit | Rate | Cost per use |
| --- | --- | --- | --- | --- |
| 16-mm Camera | Equipment |  | 6.25 |  |
| 16-mm Film | Film and Lab | 100 Feet | 20 |  |
| 500-Watt Light | Equipment |  | 2.5 |  |
| Anne L. Paper | Talent |  | 9.38 |  |
| Camera Boom | Equipment |  |  |  |
| Clair Hector | Production |  | 20 |  |
| Crane | Equipment |  |  |  |
| Daniel Penn | Talent |  | 9.38 |  |
| David Campbell | Talent |  | 9.38 |  |
| Dolly | Equipment |  |  |  |
| Doug Hampton | Production |  | 13 |  |
| Editing Lab | Film and Lab |  | 25 | 25 |
| Electrician | Crew |  | 22 |  |
| Eric Lang | Production |  | 15.5 |  |
| Eric Miller | Talent |  | 9.38 |  |
| Florian Voss | Production |  | 22 |  |
| Frank Lee | Crew |  | 14 |  |
| Jan Miksovsky | Production |  | 18.75 |  |
| Jim Hance | Talent |  | 9.38 |  |
| Jo Brown | Production |  | 18.75 |  |
| Johnathan Perrera | Production |  | 22 |  |
| Joseph Matthews | Talent |  | 9.38 |  |
| Joshua Randall | Talent |  | 12 |  |
| Kathryn Wilson | Production |  | 5 | 100 |
| Keith Harris | Crew |  | 14 |  |
| Kim Yoshida | Production |  | 9.4 |  |
| Linda Kobara | Production |  | 24 |  |
| Lisa Garmaise | Production |  | 9 |  |
| Mark Hassall | Production |  | 23.75 |  |
| Max Benson | Crew |  | 24 |  |
| Megan Sherman | Crew |  | 18 |  |
| Michael Patten | Production |  | 17.5 |  |
| Pat Kirtland | Production |  | 5.62 |  |
| Paul Borm | Production |  | 25 |  |
| Reflector Kit | Equipment |  |  |  |
| Richard Lum | Production |  | 15.62 |  |
| Salman Mughal | Production |  | 18 |  |
| Scott Cooper | Production |  | 19.37 |  |
| Sue Jackson | Talent |  | 9.38 |  |
| Ted Bremer | Crew |  | 14 |  |
| Tim O'Brien | Crew |  | 14 |  |

## Schedule

| ID | WBS | Task | Type | Duration | Start | Finish | Predecessors | Complete | Remaining | Baseline start | Baseline finish | Baseline duration | Total slack | Free slack | Constraint | Deadline | Calendar | Resources | Work | Actual work | Cost | Baseline cost | Actual cost | Text9 | Text10 |
| --- | --- | --- | --- | --- | --- | --- | --- | --- | --- | --- | --- | --- | --- | --- | --- | --- | --- | --- | --- | --- | --- | --- | --- | --- | --- |
| 1 | 1 | **Pre-Production** |  | 57.5d | 2005-03-07 A | 2005-05-25 A |  | 100% |  | 2005-03-07 | 2005-05-25 | 57.5d |  |  |  |  |  |  | 1204h | 1204h | 23,089.75 | 23,089.75 | 23,089.75 |  |  |
| 2 | 1.1 | Review script |  | 1w | 2005-03-07 A | 2005-03-11 A |  | 100% |  | 2005-03-07 | 2005-03-11 | 1w |  |  |  |  |  | Scott Cooper [50%]; Clair Hector | 48h | 48h | 947.5 | 947.5 | 947.5 |  |  |
| 3 | 1.2 | Develop script breakdown and schedule |  | 1.05w | 2005-03-14 A | 2005-03-21 A | 2 | 100% |  | 2005-03-14 | 2005-03-21 | 1.05w |  |  |  |  |  | Scott Cooper; Johnathan Perrera; Clair Hector | 120h | 120h | 2,455 | 2,455 | 2,455 |  |  |
| 4 | 1.3 | Develop production boards |  | 3w | 2005-03-21 A | 2005-04-12 A | 3 | 100% |  | 2005-03-21 | 2005-04-12 | 3w |  |  |  |  |  | Scott Cooper; Kim Yoshida; Johnathan Perrera | 348h | 348h | 5,844.75 | 5,844.75 | 5,844.75 |  |  |
| 5 | 1.4 | Review production boards |  | 1w | 2005-04-12 A | 2005-04-19 A | 4 | 100% |  | 2005-04-12 | 2005-04-19 | 1w |  |  |  |  |  | Clair Hector; Scott Cooper | 80h | 80h | 1,575 | 1,575 | 1,575 |  |  |
| 6 | 1.5 | Scout locations |  | 2w | 2005-04-19 A | 2005-05-03 A | 5 | 100% |  | 2005-04-19 | 2005-05-03 | 2w |  |  |  |  |  | Jo Brown; Jan Miksovsky; Max Benson | 240h | 240h | 4,920 | 4,920 | 4,920 |  |  |
| 7 | 1.6 | Select locations |  | 1.05w | 2005-05-03 A | 2005-05-10 A | 6 | 100% |  | 2005-05-03 | 2005-05-10 | 1.05w |  |  |  |  |  | Scott Cooper; Clair Hector; Max Benson | 120h | 120h | 2,535 | 2,535 | 2,535 |  |  |
| 8 | 1.7 | Hold auditions |  | 1.05w | 2005-05-10 A | 2005-05-17 A | 7 | 100% |  | 2005-05-10 | 2005-05-17 | 1.05w |  |  |  |  |  | Clair Hector; Scott Cooper; Doug Hampton [50%] | 100h | 100h | 1,887 | 1,887 | 1,887 |  |  |
| 9 | 1.8 | Apply for filming permits |  | 1w | 2005-05-18 A | 2005-05-24 A | 8 | 100% |  | 2005-05-18 | 2005-05-24 | 1w |  |  |  |  |  | Kim Yoshida | 40h | 40h | 876 | 876 | 876 |  |  |
| 10 | 1.9 | Reserve camera equipment |  | 3d | 2005-05-20 A | 2005-05-25 A | 9FS-5% | 100% |  | 2005-05-20 | 2005-05-25 | 3d |  |  |  |  |  | Jan Miksovsky; Eric Lang [50%] | 36h | 36h | 636 | 636 | 636 |  |  |
| 11 | 1.10 | Reserve sound equipment |  | 3d | 2005-05-20 A | 2005-05-25 A | 10SS | 100% |  | 2005-05-20 | 2005-05-25 | 3d |  |  |  |  |  | Eric Lang [50%] | 12h | 12h | 186 | 186 | 186 |  |  |
| 12 | 1.11 | Pre-Production complete! | milestone | 0d | 2005-05-25 A | 2005-05-25 A | 11 | 100% |  | 2005-05-25 | 2005-05-25 | 0d |  |  |  | 2005-05-27 |  |  |  |  |  |  |  |  |  |
| 13 | 1.12 | **Staff planning meeting** |  | 45.25d | 2005-03-14 A | 2005-05-16 A |  | 100% |  | 2005-03-14 | 2005-05-16 | 45.25d |  |  |  |  |  |  | 60h | 60h | 1,227.5 | 1,227.5 | 1,227.5 |  |  |
| 14 | 1.12.1 | Staff planning meeting 1 |  | 2h | 2005-03-14 A | 2005-03-14 A |  | 100% |  | 2005-03-14 | 2005-03-14 | 2h |  |  | start no earlier than 2005-03-14 |  |  | Clair Hector; Johnathan Perrera; Scott Cooper | 6h | 6h | 122.75 | 122.75 | 122.75 |  |  |
| 15 | 1.12.2 | Staff planning meeting 2 |  | 2h | 2005-03-21 A | 2005-03-21 A |  | 100% |  | 2005-03-21 | 2005-03-21 | 2h |  |  | start no earlier than 2005-03-21 |  |  | Clair Hector; Johnathan Perrera; Scott Cooper | 6h | 6h | 122.75 | 122.75 | 122.75 |  |  |
| 16 | 1.12.3 | Staff planning meeting 3 |  | 2h | 2005-03-28 A | 2005-03-28 A |  | 100% |  | 2005-03-28 | 2005-03-28 | 2h |  |  | start no earlier than 2005-03-28 |  |  | Clair Hector; Johnathan Perrera; Scott Cooper | 6h | 6h | 122.75 | 122.75 | 122.75 |  |  |
| 17 | 1.12.4 | Staff planning meeting 4 |  | 2h | 2005-04-04 A | 2005-04-04 A |  | 100% |  | 2005-04-04 | 2005-04-04 | 2h |  |  | start no earlier than 2005-04-04 |  |  | Clair Hector; Johnathan Perrera; Scott Cooper | 6h | 6h | 122.75 | 122.75 | 122.75 |  |  |
| 18 | 1.12.5 | Staff planning meeting 5 |  | 2h | 2005-04-11 A | 2005-04-11 A |  | 100% |  | 2005-04-11 | 2005-04-11 | 2h |  |  | start no earlier than 2005-04-11 |  |  | Clair Hector; Johnathan Perrera; Scott Cooper | 6h | 6h | 122.75 | 122.75 | 122.75 |  |  |
| 19 | 1.12.6 | Staff planning meeting 6 |  | 2h | 2005-04-18 A | 2005-04-18 A |  | 100% |  | 2005-04-18 | 2005-04-18 | 2h |  |  | start no earlier than 2005-04-18 |  |  | Clair Hector; Johnathan Perrera; Scott Cooper | 6h | 6h | 122.75 | 122.75 | 122.75 |  |  |
| 20 | 1.12.7 | Staff planning meeting 7 |  | 2h | 2005-04-25 A | 2005-04-25 A |  | 100% |  | 2005-04-25 | 2005-04-25 | 2h |  |  | start no earlier than 2005-04-25 |  |  | Clair Hector; Johnathan Perrera; Scott Cooper | 6h | 6h | 122.75 | 122.75 | 122.75 |  |  |
| 21 | 1.12.8 | Staff planning meeting 8 |  | 2h | 2005-05-02 A | 2005-05-02 A |  | 100% |  | 2005-05-02 | 2005-05-02 | 2h |  |  | start no earlier than 2005-05-02 |  |  | Clair Hector; Johnathan Perrera; Scott Cooper | 6h | 6h | 122.75 | 122.75 | 122.75 |  |  |
| 22 | 1.12.9 | Staff planning meeting 9 |  | 2h | 2005-05-09 A | 2005-05-09 A |  | 100% |  | 2005-05-09 | 2005-05-09 | 2h |  |  | start no earlier than 2005-05-09 |  |  | Clair Hector; Johnathan Perrera; Scott Cooper | 6h | 6h | 122.75 | 122.75 | 122.75 |  |  |
| 23 | 1.12.10 | Staff planning meeting 10 |  | 2h | 2005-05-16 A | 2005-05-16 A |  | 100% |  | 2005-05-16 | 2005-05-16 | 2h |  |  | start no earlier than 2005-05-16 |  |  | Clair Hector; Johnathan Perrera; Scott Cooper | 6h | 6h | 122.75 | 122.75 | 122.75 |  |  |
| 24 | 2 | **Production** |  | 61.5d | 2005-05-25 A | 2005-08-19 | 1 | 40% | 36.85d | 2005-05-25 | 2005-08-02 | 48.5d | -5d | 0d |  | 2005-08-12 |  |  | 2617h | 1236h | 43,910.72 | 36,380.95 | 21,373.08 |  |  |
| 25 | 2.1 | **Scene 7** |  | 4.5d | 2005-05-25 A | 2005-06-01 A |  | 100% |  | 2005-05-25 | 2005-06-01 | 4.5d |  |  |  |  |  |  | 216h | 216h | 3,711.88 | 3,702.5 | 3,711.88 |  |  |
| 26 | 2.1.1 | Scene 7 setup |  | 6h | 2005-05-25 A | 2005-05-26 A |  | 100% |  | 2005-05-25 | 2005-05-26 | 6h |  |  |  |  |  | Jo Brown; Max Benson; Electrician [50%] | 15h | 15h | 322.5 | 322.5 | 322.5 |  |  |
| 27 | 2.1.2 | Scene 7 rehearsal |  | 12h | 2005-05-26 A | 2005-05-27 A | 26 | 100% |  | 2005-05-26 | 2005-05-27 | 8h |  |  |  |  |  | Scott Cooper [91.7%]; Jo Brown; Paul Borm [50%]; Joseph Matthews [116.7%]; Sue Jackson; Jan Miksovsky | 45h | 45h | 714.38 | 705 | 714.38 |  |  |
| 28 | 2.1.3 | Scene 7 shoot |  | 8h | 2005-05-27 A | 2005-05-30 A | 27 | 100% |  | 2005-05-27 | 2005-05-30 | 8h |  |  |  |  |  | Scott Cooper; Jo Brown; Joseph Matthews; Sue Jackson; Frank Lee; Keith Harris; Ted Bremer; 16-mm Camera [300%]; 500-Watt Light [200%]; Joshua Randall; Megan Sherman; Tim O'Brien; Jan Miksovsky; Camera Boom; 16-mm Film [5 100 Feet] | 136h | 136h | 2,245 | 2,245 | 2,245 | Richard, Store clerk #1, Store clerk #2 | Grocery store |
| 29 | 2.1.4 | Scene 7 teardown |  | 8h | 2005-05-30 A | 2005-05-31 A | 28 | 100% |  | 2005-05-30 | 2005-05-31 | 8h |  |  |  |  |  | Jo Brown; Max Benson; Electrician [50%] | 20h | 20h | 430 | 430 | 430 |  |  |
| 30 | 2.1.5 | Scene 7-process dailies |  | 1d | 2005-05-31 A | 2005-06-01 A | 29 | 100% |  | 2005-05-31 | 2005-06-01 | 1d |  |  |  |  | Night Shift |  |  |  |  |  |  |  |  |

| ID | WBS | Task | Duration | Start | Finish | Predecessors | Complete | Baseline start | Baseline finish | Baseline duration | Total slack | Free slack | Constraint | Calendar | Resources | Work | Actual work | Cost | Baseline cost | Actual cost | Text9 | Text10 |
| --- | --- | --- | --- | --- | --- | --- | --- | --- | --- | --- | --- | --- | --- | --- | --- | --- | --- | --- | --- | --- | --- | --- |
| 31 | 2.2 | **Scene 3** | 4d | 2005-06-01 A | 2005-06-06 A | 25 | 100% | 2005-06-01 | 2005-06-06 | 4d |  |  |  |  |  | 268h | 268h | 4,180.4 | 4,180.4 | 4,180.4 |  |  |
| 32 | 2.2.1 | Scene 3 setup | 1d | 2005-06-01 A | 2005-06-01 A |  | 100% | 2005-06-01 | 2005-06-01 | 1d |  |  | start no earlier than 2004-05-24 |  | Jo Brown; Max Benson; Electrician | 24h | 24h | 518 | 518 | 518 |  |  |
| 33 | 2.2.2 | Scene 3 rehearsal | 1d | 2005-06-02 A | 2005-06-02 A | 32 | 100% | 2005-06-02 | 2005-06-02 | 1d |  |  |  |  | Scott Cooper; Jo Brown; Eric Miller; Jim Hance; Anne L. Paper; Joseph Matthews; Jan Miksovsky | 56h | 56h | 755 | 755 | 755 |  |  |
| 34 | 2.2.3 | Scene 3 shoot | 8h | 2005-06-03 A | 2005-06-03 A | 33 | 100% | 2005-06-03 | 2005-06-03 | 8h |  |  |  |  | Scott Cooper; Jo Brown; Eric Miller; Jim Hance; Anne L. Paper; Joseph Matthews; Tim O'Brien; Megan Sherman; Doug Hampton [50%]; Keith Harris; 16-mm Camera [200%]; 500-Watt Light [400%]; Dolly; Frank Lee; Jan Miksovsky; Ted Bremer; Camera Boom; 16-mm Film [5 100 Feet] | 164h | 164h | 2,389.4 | 2,389.4 | 2,389.4 | Man on street, Richard | Street corner |
| 35 | 2.2.4 | Scene 3 teardown | 1d | 2005-06-06 A | 2005-06-06 A | 34 | 100% | 2005-06-06 | 2005-06-06 | 1d |  |  |  |  | Jo Brown; Max Benson; Electrician | 24h | 24h | 518 | 518 | 518 |  |  |
| 36 | 2.2.5 | Scene 3-process dailies | 1d | 2005-06-03 A | 2005-06-04 A | 34 | 100% | 2005-06-03 | 2005-06-04 | 1d |  |  |  | Night Shift |  |  |  |  |  |  |  |  |
| 37 | 2.3 | **Scene 1** | 19d | 2005-06-07 A | 2005-07-01 A | 31 | 100% | 2005-06-07 | 2005-06-14 | 6d |  |  |  |  |  | 752h | 752h | 13,480.8 | 5,960.4 | 13,480.8 |  |  |
| 38 | 2.3.1 | Scene 1 setup | 5d | 2005-06-07 A | 2005-06-16 A |  | 100% | 2005-06-07 | 2005-06-09 | 3d |  |  |  |  | Jo Brown; Max Benson; Electrician [200%] | 160h | 160h | 3,470 | 2,082 | 3,470 |  |  |
| 39 | 2.3.2 | Scene 1 rehearsal | 4d | 2005-06-17 A | 2005-06-24 A | 38 | 100% | 2005-06-10 | 2005-06-10 | 1d |  |  | start no earlier than 2005-06-12 |  | Scott Cooper; Jo Brown; Paul Borm [50%]; David Campbell; Eric Miller; Sue Jackson; Jan Miksovsky | 208h | 208h | 3,120 | 780 | 3,120 |  |  |
| 40 | 2.3.3 | Scene 1 shoot | 16h | 2005-06-27 A | 2005-06-28 A | 39 | 100% | 2005-06-13 | 2005-06-13 | 8h |  |  |  |  | Scott Cooper; Jo Brown; Paul Borm [50%]; David Campbell; Eric Miller; Sue Jackson; Tim O'Brien; Frank Lee; Megan Sherman; Doug Hampton [50%]; Keith Harris; Ted Bremer; 16-mm Camera [300%]; 500-Watt Light; Jan Miksovsky; Dolly; Camera Boom; 16-mm Film [5 100 Feet] | 288h | 288h | 4,808.8 | 2,404.4 | 4,808.8 | Garth, Man on street, Store clerk #1 | Street corner |
| 41 | 2.3.4 | Scene 1 teardown | 3d | 2005-06-29 A | 2005-07-01 A | 40 | 100% | 2005-06-14 | 2005-06-14 | 1d |  |  |  |  | Jo Brown; Max Benson; Electrician [200%] | 96h | 96h | 2,082 | 694 | 2,082 |  |  |
| 42 | 2.3.5 | Scene 1-process dailies | 1d | 2005-06-28 A | 2005-06-29 A | 40 | 100% | 2005-06-13 | 2005-06-14 | 1d |  |  |  | Night Shift |  |  |  |  |  |  |  |  |
| 43 | 2.4 | **Scene 2** | 3d | 2005-07-04 | 2005-07-07 | 37 |  | 2005-06-15 | 2005-06-18 | 3d | -5d | 0d |  |  |  | 138h |  | 2,257.1 | 2,257.1 |  |  |  |
| 44 | 2.4.1 | Scene 2 setup | 1d | 2005-07-04 | 2005-07-04 |  |  | 2005-06-15 | 2005-06-15 | 1d | -5d | 0d |  |  | Jo Brown; Max Benson; Electrician | 24h |  | 518 | 518 |  |  |  |
| 45 | 2.4.2 | Scene 2 rehearsal | 8h | 2005-07-05 | 2005-07-05 | 44 |  | 2005-06-16 | 2005-06-16 | 8h | -5d | 0d |  |  | Scott Cooper; Doug Hampton [50%]; David Campbell; Anne L. Paper; Jan Miksovsky | 36h |  | 517.4 | 517.4 |  |  |  |
| 46 | 2.4.3 | Scene 2 shoot | 4h | 2005-07-05 | 2005-07-05 | 45 |  | 2005-06-16 | 2005-06-16 | 4h | -3.5d | 0d |  | Evening Shoot | Scott Cooper; Doug Hampton [50%]; Anne L. Paper; Tim O'Brien; Frank Lee; Keith Harris; Ted Bremer; 16-mm Camera [200%]; 500-Watt Light [300%]; Jan Miksovsky; David Campbell; Camera Boom; Crane; Dolly; 16-mm Film [5 100 Feet] | 66h |  | 962.7 | 962.7 |  | Garth, Shelly | Shelly's living room |
| 47 | 2.4.4 | Scene 2 teardown | 0.5d | 2005-07-06 | 2005-07-06 | 46 |  | 2005-06-17 | 2005-06-17 | 0.5d | -4.5d | 0d |  |  | Jo Brown; Max Benson; Electrician | 12h |  | 259 | 259 |  |  |  |
| 48 | 2.4.5 | Scene 2-process dailies | 1d | 2005-07-06 | 2005-07-07 | 47 |  | 2005-06-17 | 2005-06-18 | 1d | -5d | 0d |  | Night Shift |  |  |  |  |  |  |  |  |
| 49 | 2.5 | **Scene 5** | 6d | 2005-07-07 | 2005-07-14 | 43 |  | 2005-06-20 | 2005-06-27 | 6d | -4.5d | 0d |  |  |  | 288h |  | 4,547.4 | 4,547.4 |  |  |  |
| 50 | 2.5.1 | Scene 5 setup | 3d | 2005-07-07 | 2005-07-11 |  |  | 2005-06-20 | 2005-06-22 | 3d | -4.5d | 0d |  |  | Jo Brown; Max Benson | 48h |  | 1,026 | 1,026 |  |  |  |
| 51 | 2.5.2 | Scene 5 rehearsal | 1d | 2005-07-12 | 2005-07-12 | 50 |  | 2005-06-23 | 2005-06-23 | 1d | -4.5d | 0d |  |  | Scott Cooper; Jo Brown; Eric Miller; David Campbell; Sue Jackson; Daniel Penn; Anne L. Paper; Jan Miksovsky [50%] | 60h |  | 755 | 755 |  |  |  |
| 52 | 2.5.3 | Scene 5 shoot | 8h | 2005-07-13 | 2005-07-13 | 51 |  | 2005-06-24 | 2005-06-24 | 8h | -4.5d | 0d |  |  | Scott Cooper; Jo Brown; Eric Miller; David Campbell; Sue Jackson; Daniel Penn; Anne L. Paper; Tim O'Brien; Frank Lee; Megan Sherman; Doug Hampton [50%]; Keith Harris; Ted Bremer; 16-mm Camera [200%]; 500-Watt Light [200%]; Crane; Jan Miksovsky; Camera Boom; Dolly; 16-mm Film [5 100 Feet] | 164h |  | 2,424.4 | 2,424.4 |  | Man on street, Garth, Old man, Shelly | Street corner |
| 53 | 2.5.4 | Scene 5 teardown | 1d | 2005-07-14 | 2005-07-14 | 52 |  | 2005-06-27 | 2005-06-27 | 1d | -4.5d | 0d |  |  | Jo Brown; Max Benson | 16h |  | 342 | 342 |  |  |  |
| 54 | 2.5.5 | Scene 5-process dailies | 1d | 2005-07-13 | 2005-07-14 | 52 |  | 2005-06-24 | 2005-06-25 | 1d | -4d | 0d |  | Night Shift |  |  |  |  |  |  |  |  |

Notes:
- 32: This scene must be shot after 5/24 due to limited access to site

| ID | WBS | Task | Duration | Start | Finish | Predecessors | Baseline start | Baseline finish | Baseline duration | Total slack | Free slack | Calendar | Resources | Work | Cost | Baseline cost | Text9 | Text10 |
| --- | --- | --- | --- | --- | --- | --- | --- | --- | --- | --- | --- | --- | --- | --- | --- | --- | --- | --- |
| 55 | 2.6 | **Scene 6** | 13d | 2005-07-15 | 2005-08-03 | 49 | 2005-06-28 | 2005-07-15 | 13d | -5d | 0d |  |  | 544h | 8,723.4 | 8,723.4 |  |  |
| 56 | 2.6.1 | Scene 6 setup | 6d | 2005-07-15 | 2005-07-22 |  | 2005-06-28 | 2005-07-05 | 6d | -4.5d | 0d |  | Jo Brown; Max Benson | 96h | 2,052 | 2,052 |  |  |
| 57 | 2.6.2 | Scene 6 rehearsal | 2d | 2005-07-25 | 2005-07-26 | 56 | 2005-07-06 | 2005-07-07 | 2d | -4.5d | 0d |  | Scott Cooper; Jo Brown; Doug Hampton [50%]; Paul Borm [50%]; David Campbell; Sue Jackson; Anne L. Paper; Jim Hance; Daniel Penn; Jan Miksovsky [50%] | 136h | 1,834.8 | 1,834.8 |  |  |
| 58 | 2.6.3 | Scene 6 shoot | 1.5d | 2005-07-27 | 2005-07-28 | 57 | 2005-07-08 | 2005-07-11 | 1.5d | -4.5d | 0d |  | Scott Cooper; Jo Brown; Doug Hampton [50%]; Paul Borm [50%]; David Campbell; Sue Jackson; Anne L. Paper; Jim Hance; Daniel Penn; Frank Lee; Megan Sherman; Keith Harris; Ted Bremer; 16-mm Camera [300%]; 500-Watt Light [300%]; Dolly; Crane; Joshua Randall; Tim O'Brien; 16-mm Film [5 100 Feet] | 264h | 3,810.6 | 3,810.6 | Garth, Store Clerk #1, Shelly, Old man | Grocery store |
| 59 | 2.6.4 | Scene 6 teardown | 3d | 2005-07-28 | 2005-08-02 | 58 | 2005-07-11 | 2005-07-14 | 3d | -4.5d | 0d |  | Jo Brown; Max Benson | 48h | 1,026 | 1,026 |  |  |
| 60 | 2.6.5 | Scene 6-process dailies | 1d | 2005-08-02 | 2005-08-03 | 59 | 2005-07-14 | 2005-07-15 | 1d | -5d | 0d | Night Shift |  |  |  |  |  |  |
| 61 | 2.7 | **Scene 8** | 8d | 2005-08-03 | 2005-08-13 | 55 | 2005-07-15 | 2005-07-27 | 8d | -5d | 0d |  |  | 320h | 5,278.2 | 5,278.2 |  |  |
| 62 | 2.7.1 | Scene 8 setup | 3d | 2005-08-03 | 2005-08-05 |  | 2005-07-15 | 2005-07-19 | 3d | -4.5d | 0d |  | Jo Brown; Max Benson | 48h | 1,026 | 1,026 |  |  |
| 63 | 2.7.2 | Scene 8 rehearsal | 2d | 2005-08-08 | 2005-08-09 | 62 | 2005-07-20 | 2005-07-21 | 2d | -4.5d | 0d |  | Scott Cooper; Jo Brown; Doug Hampton [50%]; Paul Borm [50%]; David Campbell; Sue Jackson; Eric Miller; Jan Miksovsky [50%] | 104h | 1,534.8 | 1,534.8 |  |  |
| 64 | 2.7.3 | Scene 8 shoot | 8h | 2005-08-10 | 2005-08-10 | 63 | 2005-07-22 | 2005-07-22 | 8h | -4.5d | 0d |  | Scott Cooper; Jo Brown; Doug Hampton [50%]; Paul Borm [50%]; David Campbell; Sue Jackson; Eric Miller; Tim O'Brien; Frank Lee; Megan Sherman; Keith Harris; Ted Bremer; 16-mm Camera [200%]; 500-Watt Light; Dolly [200%]; Camera Boom; Crane; 16-mm Film [5 100 Feet] | 144h | 2,204.4 | 2,204.4 | Garth, Store clerk #1, Man on street | Street corner |
| 65 | 2.7.4 | Scene 8 teardown | 1.5d | 2005-08-11 | 2005-08-12 | 64 | 2005-07-25 | 2005-07-26 | 1.5d | -4.5d | 0d |  | Jo Brown; Max Benson | 24h | 513 | 513 |  |  |
| 66 | 2.7.5 | Scene 8-process dailies | 1d | 2005-08-12 | 2005-08-13 | 65 | 2005-07-26 | 2005-07-27 | 1d | -5d | 0d | Night Shift |  |  |  |  |  |  |
| 67 | 2.8 | **Scene 4** | 4d | 2005-08-15 | 2005-08-19 | 61 | 2005-07-27 | 2005-08-02 | 4d | -5d | 0d |  |  | 91h | 1,731.55 | 1,731.55 |  |  |
| 68 | 2.8.1 | Scene 4 setup | 1.5d | 2005-08-15 | 2005-08-16 |  | 2005-07-27 | 2005-07-28 | 1.5d | -4.75d | 0d |  | Jo Brown; Max Benson | 24h | 513 | 513 |  |  |
| 69 | 2.8.2 | Scene 4 rehearsal | 4h | 2005-08-16 | 2005-08-16 | 68 | 2005-07-28 | 2005-07-28 | 4h | -4.75d | 0d |  | Scott Cooper; Doug Hampton [50%]; Anne L. Paper; Joseph Matthews; Jan Miksovsky [50%] | 16h | 221.2 | 221.2 |  |  |
| 70 | 2.8.3 | Scene 4 shoot | 2h | 2005-08-17 | 2005-08-17 | 69 | 2005-07-29 | 2005-07-29 | 2h | -4.75d | 0d |  | Scott Cooper; Doug Hampton [50%]; Anne L. Paper; Joseph Matthews; Frank Lee; Megan Sherman; Keith Harris; 16-mm Camera [200%]; 500-Watt Light [200%]; Jan Miksovsky; Ted Bremer; Camera Boom; 16-mm Film [5 100 Feet] | 27h | 484.35 | 484.35 | Shelly, Richard | Elevator |
| 71 | 2.8.4 | Scene 4 teardown | 1.5d | 2005-08-17 | 2005-08-18 | 70 | 2005-07-29 | 2005-08-01 | 1.5d | -4.75d | 0d |  | Jo Brown; Max Benson | 24h | 513 | 513 |  |  |
| 72 | 2.8.5 | Scene 4-process dailies | 1d | 2005-08-18 | 2005-08-19 | 71 | 2005-08-01 | 2005-08-02 | 1d | -5d | 0d | Night Shift |  |  |  |  |  |  |
| 73 | 3 | **Post-Production** | 100.5d | 2005-08-19 | 2006-01-06 | 24 | 2005-08-02 | 2005-12-20 | 100.5d | 0d |  |  |  | 1726h | 28,467.9 | 28,467.9 |  |  |
| 74 | 3.1 | Log footage | 8.5d | 2005-08-19 | 2005-08-31 |  | 2005-08-02 | 2005-08-12 | 8.5d | 0d |  |  | Editing Lab; Florian Voss | 136h | 3,221 | 3,221 |  |  |
| 75 | 3.2 | Record rough narration | 12d | 2005-08-31 | 2005-09-16 | 74 | 2005-08-12 | 2005-08-30 | 12d | 0d |  |  | David Campbell; Michael Patten | 192h | 2,580 | 2,580 |  |  |
| 76 | 3.3 | Paper edit footage | 10d | 2005-09-16 | 2005-09-30 | 75 | 2005-08-30 | 2005-09-13 | 10d | 0d |  |  | Clair Hector; Kim Yoshida; Lisa Garmaise; Richard Lum | 320h | 4,322 | 4,322 |  |  |
| 77 | 3.4 | Rough cut edit | 5d | 2005-09-30 | 2005-10-07 | 76 | 2005-09-13 | 2005-09-20 | 5d | 0d |  |  | Clair Hector; Richard Lum | 80h | 1,425 | 1,425 |  |  |
| 78 | 3.5 | Fine cut edit | 10d | 2005-10-07 | 2005-10-21 | 77 | 2005-09-20 | 2005-10-04 | 10d | 0d |  |  | Clair Hector; Richard Lum; Lisa Garmaise; Kim Yoshida; Editing Lab | 400h | 6,347 | 6,347 |  |  |
| 79 | 3.6 | Hold formal approval showing | 1d | 2005-10-21 | 2005-10-24 | 78 | 2005-10-04 | 2005-10-05 | 1d | 0d |  |  | Clair Hector; Jo Brown; Mark Hassall [50%]; Scott Cooper [50%] | 24h | 482.5 | 482.5 |  |  |
| 80 | 3.7 | Record final narration | 15d | 2005-10-24 | 2005-11-14 | 79 | 2005-10-05 | 2005-10-26 | 15d | 0d |  |  | David Campbell; Michael Patten; Scott Cooper | 216h | 3,330 | 3,330 |  |  |
| 81 | 3.8 | Add head and tail titles | 1w | 2005-11-14 | 2005-11-21 | 80 | 2005-10-26 | 2005-11-02 | 1w | 0d |  |  | Jo Brown; Michael Patten; Editing Lab | 120h | 2,475 | 2,475 |  |  |
| 82 | 3.9 | Add final music | 16d | 2005-11-21 | 2005-12-13 | 81 | 2005-11-02 | 2005-11-24 | 16d | 0d |  |  | Michael Patten | 128h | 2,240 | 2,240 |  |  |
| 83 | 3.10 | Print internegative of film | 3d | 2005-12-13 | 2005-12-16 | 82 | 2005-11-24 | 2005-11-29 | 3d | 0d |  |  | Florian Voss | 24h | 528 | 528 |  |  |
| 84 | 3.11 | Clone dubbing masters of audio tape | 12d | 2005-12-16 | 2006-01-03 | 83 | 2005-11-29 | 2005-12-15 | 12d | 0d |  |  | Doug Hampton [50%] | 48h | 748.8 | 748.8 |  |  |
| 85 | 3.12 | Archive master film and audio tape | 2d | 2006-01-03 | 2006-01-05 | 84 | 2005-12-15 | 2005-12-19 | 2d | 0d |  |  | Doug Hampton [50%]; Editing Lab; Michael Patten | 30h | 628.6 | 628.6 |  |  |
| 86 | 3.13 | Hand off masters to distributor | 1d | 2006-01-05 | 2006-01-06 | 85 | 2005-12-19 | 2005-12-20 | 1d | 0d |  |  | Michael Patten | 8h | 140 | 140 |  |  |
