# Parnell Film 17a

Schedule from MS Project, 2005-07-11 to 2006-02-20, costs in $, A marks actual dates.

## Calendars

- Standard: Mon-Fri 10:00-13:00, 14:00-19:00; Sat-Sun off. Exceptions (off unless hours are given): 2005-12-23, 2005-12-26.

## Resources

| Resource | Group | Unit | Rate | Cost per use | Notes |
| --- | --- | --- | --- | --- | --- |
| Clair Hector | Production |  | 20 |  | Clair attending west coast film festival May 21 and 22, unavailable to work on project |
| Electrician | Crew |  | 22 |  |  |
| Jan Miksovsky | Production |  | 18.75 |  |  |
| Scott Cooper | Production |  | 19.37 |  |  |
| Jo Brown | Production |  | 18.75 |  |  |
| Kim Yoshida | Production |  | 9.4 |  |  |
| Peter Kelly | Production |  | 16.75 |  |  |
| John Thorson | Production |  | 15.5 |  |  |
| 5000-Watt Light | Equipment |  | 2.5 |  |  |
| Dolly | Equipment |  |  |  |  |
| Crane | Equipment |  |  |  |  |
| Editing Lab | Film and Lab |  | 25 | 50 |  |
| 16-mm Film | Film and Lab | Feet | 0.2 | 5 |  |
| 16-mm Camera | Equipment |  | 6.25 |  |  |
| Anne L. Paper | Talent |  | 9.38 |  |  |
| Daniel Penn | Talent |  | 9.38 |  |  |
| David Campbell | Talent |  | 9.38 |  |  |
| Doug Hampton | Production |  | 10 |  |  |
| Eric Lang | Production |  | 15.5 |  |  |
| Eric Miller | Talent |  | 9.38 |  |  |
| Florian Voss | Production |  | 22 |  |  |
| Frank Lee | Crew |  | 14 |  |  |
| Jim Hance | Talent |  | 9.38 |  |  |
| Johnathan Perrera | Production |  | 22 |  |  |
| Joseph Matthews | Talent |  | 9.38 |  |  |
| Joshua Randall | Talent |  | 12 |  |  |
| Kathryn Wilson | Production |  | 5 | 100 |  |
| Keith Harris | Crew |  | 14 |  |  |
| Linda Kobara | Production |  | 24 |  |  |
| Lisa Garmaise | Production |  | 9 |  |  |
| Mark Hassall | Production |  | 23.75 |  |  |
| Max Benson | Crew |  | 24 |  |  |
| Michael Patten | Production |  | 17.5 |  |  |
| Pat Kirkland | Production |  | 5.62 |  |  |
| Paul Born | Production |  | 25 |  |  |
| Richard Lum | Production |  | 15.62 |  |  |
| Salman Mughal | Production |  | 18 |  |  |
| Sue Jackson | Talent |  | 9.38 |  |  |
| Ted Bremer | Crew |  | 14 |  |  |
| Tim O'Brien | Crew |  | 14 |  |  |

## Schedule

| ID | WBS | Task | Type | Duration | Start | Finish | Predecessors | Complete | Remaining | Baseline start | Baseline finish | Baseline duration | Total slack | Resources | Work | Actual work | Cost | Baseline cost | Actual cost | Text9 | Text10 |
| --- | --- | --- | --- | --- | --- | --- | --- | --- | --- | --- | --- | --- | --- | --- | --- | --- | --- | --- | --- | --- | --- |
| 1 | 1 | **Pre-Production** |  | 67.63d | 2005-07-11 A | 2005-10-12 |  | 76% | 16.47d | 2005-07-11 | 2005-10-07 | 64.38d | 0d |  | 1278.33h | 1028.33h | 24,307.77 | 24,223.09 | 19,801.77 |  |  |
| 2 | 1.1 | Review script |  | 1w | 2005-07-11 A | 2005-07-15 A |  | 100% |  | 2005-07-11 | 2005-07-15 | 1w |  | Scott Cooper; Clair Hector | 64h | 64h | 1,260 | 1,260 | 1,260 |  |  |
| 3 | 1.2 | Develop script breakdown and schedule |  | 1.45w | 2005-07-18 A | 2005-07-28 A | 2 | 100% |  | 2005-07-18 | 2005-07-27 | 1.45w |  | Scott Cooper; John Thorson [75%]; Johnathan Perrera [50.2%] | 72h | 72h | 1,386.83 | 1,386.83 | 1,386.83 |  |  |
| 4 | 1.3 | Develop production boards |  | 5.45w | 2005-07-28 A | 2005-09-05 A | 3 | 100% |  | 2005-07-27 | 2005-08-31 | 5w |  | Scott Cooper; John Thorson [75%]; Kim Yoshida [50%]; Johnathan Perrera | 544.33h | 544.33h | 9,460.69 | 9,376.01 | 9,460.69 |  |  |
| 5 | 1.4 | Scout locations |  | 1.33w | 2005-09-05 A | 2005-09-14 A | 4 | 100% |  | 2005-08-31 | 2005-09-08 | 1.33w |  | Jo Brown; Jan Miksovsky; 16-mm Film [2160 Feet]; Max Benson | 160h | 160h | 3,717 | 3,717 | 3,717 |  |  |
| 6 | 1.5 | Select locations |  | 8d | 2005-09-14 A | 2005-09-26 A | 5 | 100% |  | 2005-09-08 | 2005-09-20 | 8d |  | Scott Cooper; Clair Hector; Max Benson | 188h | 188h | 3,977.25 | 3,977.25 | 3,977.25 |  |  |
| 7 | 1.6 | Hold auditions |  | 1w | 2005-09-26 | 2005-10-03 | 6 |  |  | 2005-09-20 | 2005-09-27 | 1w | 0d | Clair Hector; Scott Cooper; Doug Hampton [50%]; John Thorson [75%] | 130h |  | 2,300 | 2,300 |  |  |  |
| 8 | 1.7 | Apply for filming permits |  | 1w | 2005-09-28 | 2005-10-05 | 7FS-5% |  |  | 2005-09-23 | 2005-09-30 | 1w | 0d | Kim Yoshida | 40h |  | 876 | 876 |  |  |  |
| 9 | 1.8 | Reserve camera equipment |  | 0.5w | 2005-10-05 | 2005-10-10 | 8 |  |  | 2005-09-30 | 2005-10-04 | 0.5w | 0d | Jan Miksovsky; Eric Lang | 40h |  | 685 | 685 |  |  |  |
| 10 | 1.9 | Reserve sound equipment |  | 4.94d | 2005-10-05 | 2005-10-12 | 9SS |  |  | 2005-09-30 | 2005-10-07 | 4.94d | 0d | Peter Kelly; Eric Lang | 40h |  | 645 | 645 |  |  |  |
| 11 | 1.10 | Pre-Production complete! | milestone | 0d | 2005-10-12 | 2005-10-12 | 10 |  |  | 2005-10-07 | 2005-10-07 | 0d | 0d |  |  |  |  |  |  |  |  |
| 12 | 2 | **Production** |  | 34.12d | 2005-10-12 | 2005-11-29 | 1 |  |  | 2005-10-07 | 2005-11-23 | 33.12d | 0d |  | 1561h |  | 33,067.38 | 32,373.38 |  |  |  |
| 13 | 2.1 | **Scene 1** |  | 6.75d | 2005-10-12 | 2005-10-21 |  |  |  | 2005-10-07 | 2005-10-17 | 5.75d | 0d |  | 306.5h |  | 7,356.25 | 6,662.25 |  |  |  |
| 14 | 2.1.1 | Scene 1 setup |  | 4d | 2005-10-12 | 2005-10-18 |  |  |  | 2005-10-07 | 2005-10-12 | 3d | 0d | Jo Brown; Max Benson; Electrician [200%] | 128h |  | 2,776 | 2,082 |  |  |  |
| 15 | 2.1.2 | Scene 1 rehearsal |  | 1d | 2005-10-18 | 2005-10-19 | 14 |  |  | 2005-10-12 | 2005-10-13 | 1d | 0d | Scott Cooper; Jo Brown; Paul Born [50%]; David Campbell; Eric Miller; Sue Jackson; Jan Miksovsky | 52h |  | 780 | 780 |  |  |  |
| 16 | 2.1.3 | Scene 1 shoot |  | 6h | 2005-10-19 | 2005-10-20 | 15 |  |  | 2005-10-13 | 2005-10-14 | 6h | 0d | Scott Cooper; Jo Brown; Paul Born [50%]; David Campbell; Eric Miller; Sue Jackson; Tim O'Brien; Frank Lee; John Thorson [75%]; Doug Hampton [50%]; Keith Harris; Ted Bremer; 16-mm Camera [300%]; 5000-Watt Light; 16-mm Film [1620 Feet]; Jan Miksovsky | 94.5h |  | 3,106.25 | 3,106.25 |  | Garth, Pilot, Mechanic #1 | Runway tarmac |
| 17 | 2.1.4 | Scene 1 teardown |  | 1d | 2005-10-20 | 2005-10-21 | 16 |  |  | 2005-10-14 | 2005-10-17 | 1d | 0d | Jo Brown; Max Benson; Electrician [200%] | 32h |  | 694 | 694 |  |  |  |
| 18 | 2.2 | **Scene 2** |  | 2.62d | 2005-10-21 | 2005-10-26 | 13 |  |  | 2005-10-17 | 2005-10-19 | 2.62d | 0d |  | 103.5h |  | 2,228.38 | 2,228.38 |  |  |  |
| 19 | 2.2.1 | Scene 2 setup |  | 1d | 2005-10-21 | 2005-10-24 |  |  |  | 2005-10-17 | 2005-10-18 | 1d | 0d | Jo Brown; Max Benson; Electrician | 24h |  | 518 | 518 |  |  |  |
| 20 | 2.2.2 | Scene 2 rehearsal |  | 6h | 2005-10-24 | 2005-10-25 | 19 |  |  | 2005-10-18 | 2005-10-18 | 6h | 0d | Scott Cooper; Doug Hampton [50%]; David Campbell; Anne L. Paper; Jan Miksovsky | 27h |  | 380.25 | 380.25 |  |  |  |
| 21 | 2.2.3 | Scene 2 shoot |  | 3h | 2005-10-25 | 2005-10-25 | 20 |  |  | 2005-10-18 | 2005-10-19 | 3h | 0d | Scott Cooper; Doug Hampton [50%]; Anne L. Paper; Tim O'Brien; Frank Lee; Keith Harris; Ted Bremer; 16-mm Camera [200%]; 5000-Watt Light [300%]; 16-mm Film [1080 Feet]; Jan Miksovsky; David Campbell | 40.5h |  | 1,071.12 | 1,071.12 |  | Garth, Shelly | Hallway |
| 22 | 2.2.4 | Scene 2 teardown |  | 0.5d | 2005-10-25 | 2005-10-26 | 21 |  |  | 2005-10-19 | 2005-10-19 | 0.5d | 0d | Jo Brown; Max Benson; Electrician | 12h |  | 259 | 259 |  |  |  |
| 23 | 2.3 | **Scene 3** |  | 4d | 2005-10-26 | 2005-11-01 | 18 |  |  | 2005-10-19 | 2005-10-25 | 4d | 0d |  | 258h |  | 5,052 | 5,052 |  |  |  |
| 24 | 2.3.1 | Scene 3 setup |  | 1d | 2005-10-26 | 2005-10-27 |  |  |  | 2005-10-19 | 2005-10-20 | 1d | 0d | Jo Brown; Max Benson; Electrician | 24h |  | 518 | 518 |  |  |  |
| 25 | 2.3.2 | Scene 3 rehearsal |  | 1d | 2005-10-27 | 2005-10-28 | 24 |  |  | 2005-10-20 | 2005-10-21 | 1d | 0d | Scott Cooper; Jo Brown; Eric Miller; Jim Hance; Anne L. Paper; Joseph Matthews; Jan Miksovsky | 56h |  | 755 | 755 |  |  |  |
| 26 | 2.3.3 | Scene 3 shoot |  | 8h | 2005-10-28 | 2005-10-31 | 25 |  |  | 2005-10-21 | 2005-10-24 | 8h | 0d | Scott Cooper; Jo Brown; Eric Miller; Jim Hance; Anne L. Paper; Joseph Matthews; Tim O'Brien; John Thorson [75%]; Doug Hampton [50%]; Keith Harris; 16-mm Camera [200%]; 5000-Watt Light [400%]; Dolly; 16-mm Film [1080 Feet]; Frank Lee; Jan Miksovsky; Ted Bremer | 154h |  | 3,261 | 3,261 |  | Mechanic #1, Mechanic #2, Richard | Hangar |
| 27 | 2.3.4 | Scene 3 teardown |  | 1d | 2005-10-31 | 2005-11-01 | 26 |  |  | 2005-10-24 | 2005-10-25 | 1d | 0d | Jo Brown; Max Benson; Electrician | 24h |  | 518 | 518 |  |  |  |

Notes:
- 12: Production should not start before March 4, due to limited access to sound stage.

| ID | WBS | Task | Duration | Start | Finish | Predecessors | Baseline start | Baseline finish | Baseline duration | Total slack | Resources | Work | Cost | Baseline cost | Text9 | Text10 |
| --- | --- | --- | --- | --- | --- | --- | --- | --- | --- | --- | --- | --- | --- | --- | --- | --- |
| 28 | 2.4 | **Scene 4** | 2.75d | 2005-11-01 | 2005-11-03 | 23 | 2005-10-25 | 2005-10-28 | 2.75d | 0d |  | 87h | 1,850.75 | 1,850.75 |  |  |
| 29 | 2.4.1 | Scene 4 setup | 1d | 2005-11-01 | 2005-11-02 |  | 2005-10-25 | 2005-10-26 | 1d | 0d | Jo Brown; Max Benson; Peter Kelly | 24h | 476 | 476 |  |  |
| 30 | 2.4.2 | Scene 4 rehearsal | 4h | 2005-11-02 | 2005-11-02 | 29 | 2005-10-26 | 2005-10-27 | 4h | 0d | Scott Cooper; Doug Hampton [50%]; Anne L. Paper; Joseph Matthews; Jan Miksovsky [50%] | 16h | 216 | 216 |  |  |
| 31 | 2.4.3 | Scene 4 shoot | 2h | 2005-11-02 | 2005-11-02 | 30 | 2005-10-27 | 2005-10-27 | 2h | 0d | Scott Cooper; Doug Hampton [50%]; Anne L. Paper; Joseph Matthews; Frank Lee; Keith Harris; 16-mm Camera [200%]; 5000-Watt Light [200%]; 16-mm Film [1080 Feet]; Jan Miksovsky; Ted Bremer | 23h | 682.75 | 682.75 | Mechanic #2, Garth, Shelly | Hangar |
| 32 | 2.4.4 | Scene 4 teardown | 1d | 2005-11-02 | 2005-11-03 | 31 | 2005-10-27 | 2005-10-28 | 1d | 0d | Jo Brown; Max Benson; Peter Kelly | 24h | 476 | 476 |  |  |
| 33 | 2.5 | **Scene 5** | 5.5d | 2005-11-03 | 2005-11-11 | 28 | 2005-10-28 | 2005-11-07 | 5.5d | 0d |  | 262h | 5,248 | 5,248 |  |  |
| 34 | 2.5.1 | Scene 5 setup | 2.5d | 2005-11-03 | 2005-11-08 |  | 2005-10-28 | 2005-11-02 | 2.5d | 0d | Jo Brown; Max Benson | 40h | 855 | 855 |  |  |
| 35 | 2.5.2 | Scene 5 rehearsal | 1d | 2005-11-08 | 2005-11-09 | 34 | 2005-11-02 | 2005-11-03 | 1d | 0d | Scott Cooper; Jo Brown; Eric Miller; David Campbell; Sue Jackson; Daniel Penn; Anne L. Paper; Jan Miksovsky [50%] | 60h | 755 | 755 |  |  |
| 36 | 2.5.3 | Scene 5 shoot | 8h | 2005-11-09 | 2005-11-10 | 35 | 2005-11-03 | 2005-11-04 | 8h | 0d | Scott Cooper; Jo Brown; Eric Miller; David Campbell; Sue Jackson; Daniel Penn; Anne L. Paper; Tim O'Brien; Frank Lee; John Thorson [75%]; Doug Hampton [50%]; Keith Harris; Ted Bremer; 16-mm Camera [200%]; 5000-Watt Light [200%]; Crane; 16-mm Film [1080 Feet]; Jan Miksovsky | 146h | 3,296 | 3,296 | Garth, Shelly | Hallway |
| 37 | 2.5.4 | Scene 5 teardown | 1d | 2005-11-10 | 2005-11-11 | 36 | 2005-11-04 | 2005-11-07 | 1d | 0d | Jo Brown; Max Benson | 16h | 342 | 342 |  |  |
| 38 | 2.6 | **Scene 6** | 12.5d | 2005-11-11 | 2005-11-29 | 33 | 2005-11-07 | 2005-11-23 | 12.5d | 0d |  | 544h | 11,332 | 11,332 |  |  |
| 39 | 2.6.1 | Scene 6 setup | 6d | 2005-11-11 | 2005-11-21 |  | 2005-11-07 | 2005-11-15 | 6d | 0d | Jo Brown; Max Benson | 96h | 2,052 | 2,052 |  |  |
| 40 | 2.6.2 | Scene 6 rehearsal | 2d | 2005-11-21 | 2005-11-23 | 39 | 2005-11-15 | 2005-11-17 | 2d | 0d | Scott Cooper; Jo Brown; Doug Hampton [50%]; Paul Born [50%]; David Campbell; Sue Jackson; Anne L. Paper; Jim Hance; Daniel Penn; Jan Miksovsky [50%] | 136h | 1,814 | 1,814 |  |  |
| 41 | 2.6.3 | Scene 6 shoot | 12h | 2005-11-23 | 2005-11-24 | 40 | 2005-11-17 | 2005-11-18 | 12h | 0d | Scott Cooper; Jo Brown; Doug Hampton [50%]; Paul Born [50%]; David Campbell; Sue Jackson; Anne L. Paper; Jim Hance; Daniel Penn; Frank Lee; Keith Harris; Ted Bremer; 16-mm Camera [300%]; 5000-Watt Light [300%]; Dolly; Crane; 16-mm Film [1620 Feet]; Joshua Randall; Tim O'Brien; Jan Miksovsky | 264h | 6,440 | 6,440 | Garth, Pilot, Mechanic #1 | Runway tarmac |
| 42 | 2.6.4 | Scene 6 teardown | 3d | 2005-11-24 | 2005-11-29 | 41 | 2005-11-18 | 2005-11-23 | 3d | 0d | Jo Brown; Max Benson | 48h | 1,026 | 1,026 |  |  |
| 43 | 3 | **Post-Production** | 57.21d | 2005-11-29 | 2006-02-20 | 12 | 2005-11-23 | 2006-02-16 | 59.45d | 0d |  | 1689.43h | 26,097.27 | 26,097.27 |  |  |
| 44 | 3.1 | Log footage | 9.26d | 2005-11-29 | 2005-12-12 |  | 2005-11-23 | 2005-12-06 | 10d | 0d | Editing Lab; Florian Voss | 124h | 2,958 | 2,958 |  |  |
| 45 | 3.2 | Record rough narration | 6d | 2005-12-12 | 2005-12-20 | 44 | 2005-12-06 | 2005-12-13 | 6d | 0d | Peter Kelly; David Campbell; Michael Patten | 144h | 2,094 | 2,094 |  |  |
| 46 | 3.3 | Paper edit footage | 1.25w | 2005-12-20 | 2005-12-30 | 45 | 2005-12-14 | 2005-12-22 | 1.25w | 0d | Clair Hector; Kim Yoshida; Lisa Garmaise; Richard Lum | 320h | 2,701.25 | 2,701.25 |  |  |
| 47 | 3.4 | Rough cut edit | 1w | 2005-12-28 | 2006-01-04 | 46FS-5d | 2005-12-22 | 2006-01-02 | 1w | 0d | Clair Hector; Richard Lum | 80h | 1,425 | 1,425 |  |  |
| 48 | 3.5 | Fine cut edit | 2w | 2006-01-04 | 2006-01-18 | 47 | 2006-01-02 | 2006-01-16 | 2w | 0d | Clair Hector; Richard Lum; Lisa Garmaise; Kim Yoshida; Editing Lab | 400h | 6,372 | 6,372 |  |  |
| 49 | 3.6 | Hold formal approval showing | 1d | 2006-01-18 | 2006-01-19 | 48 | 2006-01-16 | 2006-01-17 | 1d | 0d | Clair Hector; Jan Miksovsky [50%]; Jo Brown; John Thorson [75%]; Doug Hampton [50%]; Mark Hassall; Scott Cooper; David Campbell [50%] | 50h | 912.5 | 912.5 |  |  |
| 50 | 3.7 | Record final narration | 3.33w | 2006-01-19 | 2006-02-10 | 49 | 2006-01-17 | 2006-02-08 | 3.33w | 0d | Peter Kelly; David Campbell; Michael Patten; Scott Cooper | 320h | 5,040 | 5,040 |  |  |
| 51 | 3.8 | Add head and tail titles | 0.64w | 2006-01-31 | 2006-02-03 | 50FS-5% | 2006-01-27 | 2006-02-01 | 0.64w | 0d | Jo Brown; John Thorson [75%]; Michael Patten; Editing Lab | 95.43h | 1,904.52 | 1,904.52 |  |  |
| 52 | 3.9 | Add final music | 1.64w | 2006-01-31 | 2006-02-10 | 51SS | 2006-01-27 | 2006-02-08 | 1.64w | 0d | Michael Patten; Peter Kelly | 80h | 1,370 | 1,370 |  |  |
| 53 | 3.10 | Clone dubbing masters of audio tape | 4d | 2006-02-10 | 2006-02-16 | 52 | 2006-02-08 | 2006-02-14 | 4d | 0d | Peter Kelly; Doug Hampton [50%] | 48h | 744 | 744 |  |  |
| 54 | 3.11 | Archive master film and audio tape | 1.19d | 2006-02-16 | 2006-02-17 | 53 | 2006-02-14 | 2006-02-15 | 1.19d | 0d | Peter Kelly; Doug Hampton [50%]; Editing Lab | 20h | 436 | 436 |  |  |
| 55 | 3.12 | Hand off masters to client | 1d | 2006-02-17 | 2006-02-20 | 54 | 2006-02-15 | 2006-02-16 | 1d | 0d | Michael Patten | 8h | 140 | 140 |  |  |
