# Parnell Aerospace Promo

Schedule from MS Project, 2005-04-18 to 2005-05-31, costs in $.

## Calendars

- Standard: Mon-Fri 08:00-12:00, 13:00-17:00; Sat-Sun off.

## Resources

| Resource | Rate | Cost per use |
| --- | --- | --- |
| Adam Barr | 25 |  |
| Ken Bergman | 17 |  |
| Ty Loren Carlson | 22 |  |
| Joanna Fuller | 17 |  |
| Stephanie Hooper | 8 |  |
| Sue Jackson | 9.5 |  |
| Jenny Lysaker | 14 |  |
| Lorraine Nay | 15 |  |
| Peter Porzuczek | 40 |  |
| Derik Stenerson | 14 |  |
| Madrona Community Orchestra | 2000 | 500 |
| Lakes & Sons |  | 250 |
| Fabrikam Inc. Sound Studio | 200 |  |
| Patricia Brooke | 16.5 |  |
| Matthew Dunn | 12 |  |
| Scott Fallon | 14 |  |
| Jon Ganio | 22 |  |
| Sherri Hart | 40 |  |
| Richard Kaplan | 32 |  |
| Mary Anne Kobylka | 8 |  |

## Schedule

| ID | Task | Type | Duration | Start | Finish | Predecessors | Total slack | Resources | Work | Cost |
| --- | --- | --- | --- | --- | --- | --- | --- | --- | --- | --- |
| 1 | Transfer soundtrack to mag. stock |  | 14d | 2005-04-18 | 2005-05-05 |  | 0d | Derik Stenerson [50%] | 56h | 784 |
| 2 | Record music |  | 7d | 2005-04-29 | 2005-05-09 | 1FS-5d | 0d | Madrona Community Orchestra; Ken Bergman; Peter Porzuczek | 168h | 115,692 |
| 3 | Sync sound |  | 1.5d | 2005-05-10 | 2005-05-11 | 2 | 0d | Sue Jackson; Peter Porzuczek | 24h | 594 |
| 4 | Mix |  | 7d | 2005-05-11 | 2005-05-20 | 3 | 0d | Peter Porzuczek; Sue Jackson; Adam Barr | 168h | 4,172 |
| 5 | Add effects |  | 3d | 2005-05-20 | 2005-05-25 | 4 | 0d | Ty Loren Carlson | 24h | 528 |
| 6 | Add optical track |  | 1d | 2005-05-20 | 2005-05-23 | 4 | 2d | Ken Bergman; Joanna Fuller | 16h | 272 |
| 7 | Split tracks |  | 3d | 2005-05-25 | 2005-05-30 | 6, 5 | 0d | Stephanie Hooper | 24h | 192 |
| 8 | Add dialog |  | 1.33d | 2005-05-30 | 2005-05-31 | 7 | 0d | Ken Bergman; Sue Jackson; Fabrikam Inc. Sound Studio | 32h | 2,415.99 |
| 9 | Release prints | milestone | 0d | 2005-05-31 | 2005-05-31 | 8 | 0d |  |  |  |
