# Wingtip Toys Commercial

Schedule from MS Project, 2005-05-02 to 2005-07-12, costs in $.

## Calendars

- Standard: Mon-Fri 08:00-12:00, 13:00-17:00; Sat-Sun off.

## Resources

| Resource | Rate |
| --- | --- |
| Ken Bergman | 17 |
| Patricia Brooke | 16.5 |
| Matthew Dunn | 12 |
| Scott Fallon | 14 |
| Jon Ganio | 22 |
| Sherri Hart | 40 |
| Richard Kaplan | 32 |
| Mary Anne Kobylka | 8 |
| Jessup Meng | 12 |
| Patti Mintz | 22 |
| Lani Ota | 21 |
| John Rodman | 18 |
| Lane Sacksteder | 12 |
| Garrett R Vargas | 11 |
| Suki White | 11.5 |
| Ray Zambroski | 21.75 |
| Fabrikam Inc. Sound Studio | 200 |

## Schedule

| ID | Task | Type | Duration | Start | Finish | Predecessors | Total slack | Resources | Work | Cost |
| --- | --- | --- | --- | --- | --- | --- | --- | --- | --- | --- |
| 1 | Log footage |  | 1w | 2005-05-02 | 2005-05-06 |  | 0d | Patricia Brooke [50%]; Jon Ganio; Mary Anne Kobylka | 100h | 1,530 |
| 2 | Record rough narration |  | 4d | 2005-05-04 | 2005-05-09 | 1FS-3d | 0d | Ken Bergman; Matthew Dunn | 64h | 928 |
| 3 | Paper edit footage |  | 2w | 2005-05-10 | 2005-05-23 | 2 | 0d | Ken Bergman; Jon Ganio; Mary Anne Kobylka | 240h | 3,760 |
| 4 | Rough cut edit |  | 1w | 2005-05-24 | 2005-05-30 | 3 | 0d | Ken Bergman; Lane Sacksteder | 80h | 1,160 |
| 5 | Fine cut edit |  | 2w | 2005-05-31 | 2005-06-13 | 4 | 0d | Patricia Brooke [50%]; Sherri Hart | 120h | 3,860 |
| 6 | Hold formal approval showing |  | 1d | 2005-06-14 | 2005-06-14 | 5 | 0d | Ken Bergman; Scott Fallon; Mary Anne Kobylka; Ray Zambroski | 32h | 486 |
| 7 | Record final narration |  | 1w | 2005-06-15 | 2005-06-21 | 6 | 0d | Fabrikam Inc. Sound Studio; Jon Ganio | 80h | 8,880 |
| 8 | Add head and tail titles |  | 1w | 2005-06-22 | 2005-06-28 | 7 | 0d | Garrett R Vargas; Mary Anne Kobylka | 80h | 760 |
| 9 | Add final music |  | 0.67w | 2005-06-27 | 2005-06-30 | 8FS-2d | 0d | Ken Bergman; John Rodman; Lane Sacksteder | 80h | 1,253.33 |
| 10 | Print internegative of film |  | 3d | 2005-06-30 | 2005-07-05 | 9 | 0d | Lane Sacksteder | 24h | 288 |
| 11 | Clone dubbing masters of audio tape |  | 4d | 2005-07-05 | 2005-07-11 | 10 | 0d | Suki White | 32h | 368 |
| 12 | Archive master film and audio tape |  | 1d | 2005-07-11 | 2005-07-12 | 11 | 0d | Suki White | 8h | 92 |
| 13 | Hand off masters to distributor | milestone | 0d | 2005-07-12 | 2005-07-12 | 12 | 0d |  |  |  |
