# Wingtip Toys Commercial

Schedule from MS Project, 2005-01-03 to 2005-01-25.

## Calendars

- Standard: Mon-Fri 08:00-12:00, 13:00-17:00; Sat-Sun off.

## Resources

| Resource | Unit | Rate | Notes |
| --- | --- | --- | --- |
| Garrett R. Vargas |  | 20 | Garrett attending West Coast film festival January 13 and 14; unavailable to work on project. |
| Jim Hance |  | 18.75 |  |
| Scott Cooper |  | 19.37 |  |
| Jo Brown |  | 18.75 |  |
| Patti Mintz |  | 9.4 |  |
| Peter Kelly |  | 16.75 |  |
| John Rodman |  | 22 |  |
| Jonathan Mollerup |  | 10 |  |
| Jon Ganio |  | 15.5 |  |
| Electrician |  | 22 |  |
| Mini-DV Camcorder |  | 6.25 |  |
| 600-Watt Light and Stand |  | 2.5 |  |
| Reflector Kit |  |  |  |
| Camera Boom |  |  |  |
| Editing Lab |  | 25 |  |
| Video Tape | 30-min. cassette | 5 |  |

## Schedule

| ID | WBS | Task | Type | Duration | Start | Finish | Predecessors | Total slack |
| --- | --- | --- | --- | --- | --- | --- | --- | --- |
| 1 | 1 | **Pre-Production** |  | 12d | 2005-01-03 | 2005-01-18 |  | 0d |
| 2 | 1.1 | Develop script |  | 5d | 2005-01-03 | 2005-01-07 |  | 0d |
| 3 | 1.2 | Develop production boards |  | 3d | 2005-01-10 | 2005-01-12 | 2 | 0d |
| 4 | 1.3 | Pick locations |  | 2d | 2005-01-13 | 2005-01-14 | 3 | 0d |
| 5 | 1.4 | Hold auditions |  | 2d | 2005-01-17 | 2005-01-18 | 4 | 0d |
| 6 | 1.5 | Pre-Production complete! | milestone | 0d | 2005-01-18 | 2005-01-18 | 5 | 0d |
| 7 | 2 | **Production** |  | 5d | 2005-01-19 | 2005-01-25 | 1 | 0d |
| 8 | 2.1 | Rehearse |  | 2d | 2005-01-19 | 2005-01-20 |  | 0d |
| 9 | 2.2 | Shoot video |  | 2d | 2005-01-21 | 2005-01-24 | 8 | 0d |
| 10 | 2.3 | Log footage |  | 1d | 2005-01-25 | 2005-01-25 | 9 | 0d |

Notes:
- 4: Includes exterior street scene and indoor studio scenes.
